# Figure 4-24

Schedule from MS Project, 2009-07-01 to 2010-06-30.
Augsburg College

## Calendars

- Standard: Mon-Fri 08:00-12:00, 13:00-17:00; Sat-Sun off.

## Schedule

| ID | WBS | Task | Type | Duration | Start | Finish | Predecessors | Total slack | Free slack | Constraint |
| --- | --- | --- | --- | --- | --- | --- | --- | --- | --- | --- |
| 1 | 1 | **Initiating** |  | 16d | 2009-07-01 | 2009-07-22 |  | 20d |  |  |
| 2 | 1.1 | Prepare stakeholder analysis |  | 3d | 2009-07-01 | 2009-07-03 |  | 20d | 0d |  |
| 3 | 1.2 | Prepare business case |  | 5d | 2009-07-06 | 2009-07-10 | 2 | 20d | 0d |  |
| 4 | 1.3 | Create project charter |  | 3d | 2009-07-13 | 2009-07-15 | 3 | 20d | 0d |  |
| 5 | 1.4 | Hold project kickoff meeting | milestone | 0d | 2009-07-15 | 2009-07-15 | 4 | 249d |  |  |
| 6 | 1.5 | Develop preliminary scope statement |  | 5d | 2009-07-16 | 2009-07-22 | 4 | 20d | 0d |  |
| 7 | 2 | **Planning** |  | 53d | 2009-07-06 | 2009-09-16 |  | 204d |  |  |
| 8 | 2.1 | **Project integration management** |  | 53d | 2009-07-06 | 2009-09-16 |  | 204d |  |  |
| 9 | 2.1.1 | Create team contract |  | 3d | 2009-07-06 | 2009-07-08 | 2 | 254d |  |  |
| 10 | 2.1.2 | Develop project management plan |  | 50d | 2009-07-09 | 2009-09-16 |  | 204d |  | start no earlier than 2009-07-08 |
| 11 | 2.2 | **Project scope management** |  | 10d | 2009-07-23 | 2009-08-05 |  | 204d |  |  |
| 12 | 2.2.1 | Develop scope statement |  | 7d | 2009-07-23 | 2009-07-31 | 6 | 204d | 0d |  |
| 13 | 2.2.2 | Create WBS and WBS dictionary |  | 3d | 2009-08-03 | 2009-08-05 | 12 | 204d | 0d |  |
| 14 | 2.3 | Project time management |  | 10d | 2009-08-06 | 2009-08-19 | 13 | 204d | 0d |  |
| 15 | 2.4 | Project cost management |  | 10d | 2009-08-06 | 2009-08-19 | 13 | 224d |  |  |
| 16 | 2.5 | Project quality management |  | 10d | 2009-08-06 | 2009-08-19 | 13 | 224d |  |  |
| 17 | 2.6 | Project human resource management |  | 10d | 2009-08-06 | 2009-08-19 | 13 | 224d |  |  |
| 18 | 2.7 | Project communications management |  | 10d | 2009-08-20 | 2009-09-02 | 14 | 214d |  |  |
| 19 | 2.8 | Project risk management |  | 10d | 2009-08-20 | 2009-09-02 | 14 | 214d |  |  |
| 20 | 2.9 | Project procurement management |  | 20d | 2009-08-20 | 2009-09-16 | 14 | 204d |  |  |
| 21 | 3 | **Executing** |  | 207.5d? | 2009-07-17 | 2010-05-04 |  | 24d |  |  |
| 22 | 3.1 | **Course design and development** |  | 94d | 2009-07-23 | 2009-12-01 |  | 20d |  |  |
| 23 | 3.1.1 | **Supplier management training:** |  | 94d | 2009-07-23 | 2009-12-01 |  | 20d |  |  |
| 24 | 3.1.1.1 | **Needs assessment** |  | 24d | 2009-07-23 | 2009-08-25 |  | 20d |  |  |
| 25 | 3.1.1.1.1 | Develop survey |  | 12d | 2009-07-23 | 2009-08-07 | 6 | 20d | 0d |  |
| 26 | 3.1.1.1.2 | Administer survey |  | 2d | 2009-08-10 | 2009-08-11 | 25 | 20d | 0d |  |
| 27 | 3.1.1.1.3 | Analyze survey results |  | 10d | 2009-08-12 | 2009-08-25 | 26 | 20d | 0d |  |
| 28 | 3.1.1.1.4 | Survey results reported to steering committee | milestone | 0d | 2009-08-25 | 2009-08-25 | 27 | 20d | 0d |  |
| 29 | 3.1.1.2 | Research of existing training |  | 15d | 2009-07-23 | 2009-08-12 | 6 | 229d |  |  |

| ID | WBS | Task | Type | Duration | Start | Finish | Predecessors | Total slack | Free slack |
| --- | --- | --- | --- | --- | --- | --- | --- | --- | --- |
| 30 | 3.1.1.3 | **Partnerships** |  | 25d | 2009-08-26 | 2009-09-29 |  | 20d |  |
| 31 | 3.1.1.3.1 | Research potential partners for providing training |  | 10d | 2009-08-26 | 2009-09-08 | 28 | 20d | 0d |
| 32 | 3.1.1.3.2 | Meet with potential partners |  | 10d | 2009-09-09 | 2009-09-22 | 31 | 20d | 0d |
| 33 | 3.1.1.3.3 | Develop partnership agreements |  | 5d | 2009-09-23 | 2009-09-29 | 32 | 20d | 0d |
| 34 | 3.1.1.4 | **Course development** |  | 40d | 2009-09-30 | 2009-11-24 |  | 20d |  |
| 35 | 3.1.1.4.1 | Develop executive course |  | 30d | 2009-09-30 | 2009-11-10 | 33 | 165d |  |
| 36 | 3.1.1.4.2 | Develop introductory course |  | 30d | 2009-09-30 | 2009-11-10 | 33 | 20d | 0d |
| 37 | 3.1.1.4.3 | Develop advanced course |  | 40d | 2009-09-30 | 2009-11-24 | 33 | 155d |  |
| 38 | 3.1.1.5 | **Pilot course** |  | 15d | 2009-11-11 | 2009-12-01 |  | 20d |  |
| 39 | 3.1.1.5.1 | Plan pilot course |  | 10d | 2009-11-11 | 2009-11-24 | 36 | 20d | 0d |
| 40 | 3.1.1.5.2 | Hold pilot course | milestone | 0d | 2009-11-24 | 2009-11-24 | 39 | 20d | 0d |
| 41 | 3.1.1.5.3 | Prepare report on pilot course |  | 3d | 2009-11-25 | 2009-11-27 | 40 | 20d | 0d |
| 42 | 3.1.1.5.4 | Review results of pilot course |  | 2d | 2009-11-30 | 2009-12-01 | 41 | 20d | 0d |
| 43 | 3.1.1.5.5 | Results reported to steering committee | milestone | 0d | 2009-12-01 | 2009-12-01 | 42 | 20d | 0d |
| 44 | 3.1.2 | Negotiating skills training |  | 80d | 2009-07-23 | 2009-11-11 | 6 | 54d | 0d |
| 45 | 3.1.3 | Project management training |  | 80d | 2009-07-23 | 2009-11-11 | 6 | 44d | 0d |
| 46 | 3.1.4 | Software applications training |  | 80d | 2009-07-23 | 2009-11-11 | 6 | 104d | 0d |
| 47 | 3.2 | **Course Administration** |  | 96d | 2009-12-15 | 2010-04-28 |  | 40d |  |
| 48 | 3.2.1 | First supplier management executive course completed | milestone | 0d | 2010-01-12 | 2010-01-12 | 43FS+30d | 20d | 0d |
| 49 | 3.2.2 | First supplier management introductory course completed | milestone | 0d | 2009-12-15 | 2009-12-15 | 43FS+10d | 50d | 0d |
| 50 | 3.2.3 | Second supplier management introductory course completed | milestone | 0d | 2010-01-26 | 2010-01-26 | 49FS+30d | 50d | 0d |
| 51 | 3.2.4 | Third supplier management introductory course completed | milestone | 0d | 2010-04-20 | 2010-04-20 | 50FS+60d | 50d |  |
| 52 | 3.2.5 | First supplier management advanced course | milestone | 0d | 2010-02-09 | 2010-02-09 | 43FS+50d | 100d |  |
| 53 | 3.2.6 | First negotiating skills course completed | milestone | 0d | 2010-01-20 | 2010-01-20 | 44FS+50d | 54d | 0d |
| 54 | 3.2.7 | Second negotiating skills course completed | milestone | 0d | 2010-04-14 | 2010-04-14 | 53FS+60d | 54d |  |
| 55 | 3.2.8 | First project management course completed | milestone | 0d | 2010-02-03 | 2010-02-03 | 45FS+60d | 44d | 0d |
| 56 | 3.2.9 | Second project management course completed | milestone | 0d | 2010-04-28 | 2010-04-28 | 55FS+60d | 44d |  |
| 57 | 3.2.10 | First software applications course completed | milestone | 0d | 2010-02-03 | 2010-02-03 | 46FS+60d | 104d |  |

| ID | WBS | Task | Type | Duration | Start | Finish | Predecessors | Total slack | Free slack | Constraint |
| --- | --- | --- | --- | --- | --- | --- | --- | --- | --- | --- |
| 58 | 3.3 | **Course Evaluation** |  | 79d? | 2010-01-13 | 2010-05-03 | 48 | 20d | 0d |  |
| 59 | 3.3.1 | Prepare evaluations of all courses |  | 76d? | 2010-01-13 | 2010-04-28 |  | 20d | 0d | start no earlier than 2009-12-15 |
| 60 | 3.3.2 | Prepare summary of all evaluations |  | 3d | 2010-04-29 | 2010-05-03 | 59 | 20d | 0d |  |
| 61 | 3.3.3 | Summary of course evaluations reported to steering committee | milestone | 0d | 2010-05-03 | 2010-05-03 | 60 | 20d | 0d |  |
| 62 | 3.4 | **Stakeholder Communications** |  | 207.5d? | 2009-07-17 | 2010-05-04 |  | 40.5d |  |  |
| 63 | 3.4.1 | **Communications regarding project and changes to training** |  | 207d? | 2009-07-17 | 2010-05-03 |  | 41d |  |  |
| 64 | 3.4.1.1 | Prepare emails, posters, memos, and other information |  | 207d? | 2009-07-17 | 2010-05-03 |  | 41d |  | finish no earlier than 2010-05-03 |
| 65 | 3.4.1.2 | Plan and hold meetings |  | 207d? | 2009-07-17 | 2010-05-03 |  | 41d |  | finish no earlier than 2010-05-03 |
| 66 | 3.4.1.3 | Prepare information for the corporate intranet |  | 207d? | 2009-07-17 | 2010-05-03 |  | 41d |  | finish no earlier than 2010-05-03 |
| 67 | 3.4.2 | Communications regarding productivity improvements |  | 40d | 2010-03-09 | 2010-05-04 | 58FS-5% | 40.5d |  |  |
| 68 | 4 | Monitoring and Controlling |  | 237d | 2009-07-02 | 2010-05-28 |  | 22d |  | start no earlier than 2009-07-02 |
| 69 | 5 | Closing |  | 21d | 2010-05-04 | 2010-06-01 | 61 | 20d |  | start no earlier than 2008-05-01 |
| 70 | 6 | Project buffer |  | 20d | 2010-06-02 | 2010-06-29 |  | 0d |  | start no earlier than 2010-06-01 |
| 71 | 7 | Project must be completed by date | milestone | 0d | 2010-06-30 | 2010-06-30 |  | 0d |  | start no earlier than 2010-06-30 |
